# E.1.1 Hovedfremdriftsplan rev.01 21.03.2022

Schedule from MS Project, 2021-11-05 to 2025-02-26.

## Calendars

- Standard: Mon-Fri 08:00-12:00, 13:00-17:00; Sat-Sun off. Exceptions (off unless hours are given): 2022-04-11 to 2022-04-18 (Påske 2022), 2022-05-16 to 2022-05-17 (17 Mai 2022), 2022-05-26 to 2022-05-27 (Kristi himmelfartsdag 2022), 2022-06-06 (Pinse 2022), 2022-07-04 to 2022-07-29 (Sommerferie 2022), 2022-12-26 to 2022-12-30 (Jul 2022), 2023-04-03 to 2023-04-10 (Påske 2023), 2023-05-01 (1 Mai 2023), 2023-05-15 to 2023-05-19 (17 Mai - Kristi himmelfartsdag 2023), 2023-05-29 (Pinse 2023), 2023-07-03 to 2023-07-28 (Sommerferie 2023), 2023-12-25 to 2024-01-01 (Jul 2023), 2024-03-25 to 2024-04-01 (Påske 2024), 2024-05-01 (1 Mai 2024), 2024-05-09 to 2024-05-10 (Kristi himmelfartsdag), 2024-05-17 (17 mai 2024 og prinse), 2024-07-08 to 2024-08-02 (Sommerferie 2024).

## Schedule

| ID | WBS | Task | Type | Duration | Start | Finish | Predecessors | Total slack | Free slack | Constraint |
| --- | --- | --- | --- | --- | --- | --- | --- | --- | --- | --- |
| 1 | 1 | **Base Sør - Plan 02 og 01** |  | 443d | 2022-02-07 | 2024-01-31 |  | 250d |  |  |
| 2 | 1.1 | Råbygg |  | 114d | 2022-02-07 | 2022-08-26 |  | 569d | 0d | finish no earlier than 2022-08-26 |
| 3 | 1.2 | Tetthus midl. K201 |  | 20d | 2022-08-15 | 2022-09-09 | 2FS-10d | 569d |  | start no earlier than 2022-05-16 |
| 4 | 1.3 | Tilkomst tekniske rom plan 01 | milestone | 0d | 2022-12-05 | 2022-12-05 | 22FS+11d | 258d | 0d | start no earlier than 2022-06-24 |
| 5 | 1.4 | Innvendige arbeider før RFE |  | 150d | 2022-12-06 | 2023-08-24 | 4 | 258d | 0d |  |
| 6 | 1.5 | Testing før RFE |  | 40d | 2023-11-22 | 2024-01-24 | 40 | 250d | 0d | start no earlier than 2023-02-06 |
| 7 | 1.6 | Ferdigbefaringer RFE-arealer |  | 5d | 2024-01-25 | 2024-01-31 | 6 | 250d | 0d |  |
| 8 | 1.7 | RFE | milestone | 0d | 2024-01-31 | 2024-01-31 | 7 | 250d |  | start no earlier than 2023-04-11 |
| 9 | 1.8 | Fasade-forblending inkl. rister, porter, vinduer, dører |  | 60d | 2023-06-08 | 2023-09-27 | 33FS-10d | 334d |  |  |
| 10 | 1.9 | Innvendige arbeider utenom RFE |  | 150d | 2023-05-11 | 2024-01-19 | 5SS+100d | 258d | 0d |  |
| 11 | 2 | **Base Nord - Plan 02 og 01** |  | 373d | 2022-05-30 | 2024-01-31 |  | 250d |  |  |
| 12 | 2.1 | Råbygg akse |  | 104d | 2022-05-30 | 2022-11-18 |  | 509d | 0d | finish no earlier than 2022-11-18 |
| 13 | 2.2 | Tetthus midl. K201 |  | 20d | 2022-11-07 | 2022-12-02 | 12FS-10d | 509d |  | finish no earlier than 2022-09-30 |
| 14 | 2.3 | Tilkomst tekniske rom plan 01 | milestone | 0d | 2023-03-24 | 2023-03-24 | 31FS+10d | 334d | 0d | start no earlier than 2022-10-21 |
| 15 | 2.4 | Innvendige arbeider før RFE |  | 100d | 2023-03-27 | 2023-09-27 | 14 | 334d |  |  |
| 16 | 2.5 | Testing før RFE |  | 40d | 2023-11-22 | 2024-01-24 | 40 | 250d | 0d |  |
| 17 | 2.6 | Ferdigbefaringer RFE-arealer |  | 5d | 2024-01-25 | 2024-01-31 | 16 | 250d | 0d | start no earlier than 2023-04-03 |
| 18 | 2.7 | RFE | milestone | 0d | 2024-01-31 | 2024-01-31 | 17 | 250d |  | start no earlier than 2023-04-11 |
| 19 | 2.8 | Fasade-forblending inkl. rister, porter, vinduer, dører |  | 60d | 2023-06-08 | 2023-09-27 | 33FS-10d | 334d |  | finish no earlier than 2023-04-28 |
| 20 | 2.9 | Innvendige arbeider utenom RFE |  | 150d | 2023-05-11 | 2024-01-19 | 10SS | 258d |  |  |
| 21 | 3 | **Klinikk Sør - Plan 1.0-2.0** |  | 361d | 2022-08-01 | 2024-02-16 |  | 238d |  |  |
| 22 | 3.1 | Råbygg |  | 80d | 2022-08-01 | 2022-11-18 |  | 238d | 0d | start no earlier than 2022-08-01 |
| 23 | 3.2 | Tilkomst tetthus | milestone | 0d | 2022-11-21 | 2022-11-21 | 22FS+1d | 238d | 0d | start no earlier than 2022-10-21 |
| 24 | 3.3 | Tetthus/fasade |  | 60d | 2022-11-22 | 2023-02-20 | 23 | 238d | 0d |  |
| 25 | 3.4 | Innvendige arbeider før RFE |  | 150d | 2023-02-21 | 2023-11-02 | 24 | 238d | 0d | start no earlier than 2022-10-10 |
| 26 | 3.5 | Testing før RFE |  | 40d | 2023-11-22 | 2024-01-24 | 40 | 250d | 0d | start no earlier than 2023-02-06 |
| 27 | 3.6 | Ferdigbefaringer RFE-arealer |  | 5d | 2024-01-25 | 2024-01-31 | 26 | 250d | 0d | start no earlier than 2023-04-03 |
| 28 | 3.7 | RFE | milestone | 0d | 2024-01-31 | 2024-01-31 | 27 | 250d |  | start no earlier than 2023-04-11 |
| 29 | 3.8 | Innvendige arbeider utenom RFE |  | 190d | 2023-04-12 | 2024-02-16 | 25SS+30d | 238d |  |  |

| ID | WBS | Task | Type | Duration | Start | Finish | Predecessors | Total slack | Free slack | Constraint |
| --- | --- | --- | --- | --- | --- | --- | --- | --- | --- | --- |
| 30 | 4 | **Klinikk Nord - Plan 1.0-3.0** |  | 365d | 2022-09-26 | 2024-04-26 |  | 139d |  |  |
| 31 | 4.1 | Råbygg |  | 115d | 2022-09-26 | 2023-03-10 |  | 139d | 0d | finish no earlier than 2023-03-10 |
| 32 | 4.2 | Tilkomst tetthus | milestone | 0d | 2023-03-10 | 2023-03-10 | 31 | 139d | 0d |  |
| 33 | 4.3 | Tetthus/fasade |  | 60d | 2023-03-13 | 2023-06-21 | 32 | 139d | 0d |  |
| 34 | 4.4 | Innvendige arbeider og fasade inkl. MR |  | 190d | 2023-06-22 | 2024-04-26 | 33 | 139d | 0d |  |
| 35 | 5 | **Bunker - Plan 1.0-3.0** |  | 759d | 2021-11-05 | 2025-02-26 |  | 0d |  |  |
| 36 | 5.1 | Råbygg |  | 334d | 2021-11-05 | 2023-04-14 |  | 0d |  | finish no earlier than 2023-04-14 |
| 37 | 5.2 | Tetthus og prov. Tak |  | 30d | 2023-04-17 | 2023-06-06 | 36 | 0d |  | finish no earlier than 2021-12-02 |
| 38 | 5.3 | Midl. Tetthus bunker | milestone | 0d | 2023-06-06 | 2023-06-06 | 37 | 0d |  | start no earlier than 2022-12-15 |
| 39 | 5.4 | Forblending betongfasade |  | 80d | 2023-04-17 | 2023-09-12 | 36 | 345d |  |  |
| 40 | 5.5 | Innvendige arbeider før RFE |  | 100d | 2023-06-07 | 2023-11-21 | 38 | 0d |  |  |
| 41 | 5.6 | Testing før RFE |  | 40d | 2023-11-22 | 2024-01-24 | 40 | 0d |  | start no earlier than 2023-02-06 |
| 42 | 5.7 | Ferdigbefaringer RFE-arealer |  | 5d | 2024-01-25 | 2024-01-31 | 41 | 0d |  |  |
| 43 | 5.8 | RFE-arealer - kontroller Varian |  | 40d | 2023-11-01 | 2024-01-04 | 44SF | 270d |  | start no earlier than 2023-02-27 |
| 44 | 5.9 | Varian arbeider før RFE |  | 20d | 2024-01-04 | 2024-01-31 | 45SF | 250d | 0d |  |
| 45 | 5.10 | RFE | milestone | 0d | 2024-01-31 | 2024-01-31 | 42 | 0d |  |  |
| 46 | 5.11 | Varian installasjoner etter RFE |  | 250d | 2024-02-01 | 2025-02-26 | 45 | 0d |  |  |
| 47 | 5.12 | Innvendige arbeider utenom RFE |  | 150d | 2023-06-21 | 2024-02-21 | 40SS+10d | 235d |  |  |
| 48 | 5.13 | Sluttføre maze og behandlingsrom |  | 40d | 2024-05-06 | 2024-07-03 | 45FS+60d | 150d |  |  |
| 49 | 6 | **Utomhusarbeider og P-etasje** |  | 210d | 2023-06-22 | 2024-05-30 |  | 174d |  |  |
| 50 | 6.1 | Arbeider på takflater |  | 200d | 2023-06-22 | 2024-05-15 | 33 | 184d |  |  |
| 51 | 6.2 | Utvendige veier, plasser og terrengtilpasninger |  | 170d | 2023-06-22 | 2024-03-21 | 33 | 214d |  |  |
| 52 | 6.3 | Ferdigstille parkeringsarealer plan 02 |  | 50d | 2024-03-08 | 2024-05-30 | 34FS-30d | 174d |  | start no earlier than 2023-10-02 |
| 53 | 7 | **Testing, ferdigbefaringer og overtagelser** |  | 40d | 2024-05-24 | 2024-08-15 |  | 139d |  |  |
| 54 | 7.1 | Testing anlegg utenom RFE |  | 25d | 2024-05-24 | 2024-06-27 | 34FS+15d | 139d | 0d |  |
| 55 | 7.2 | Ferdigbefaringer alle fag - øvrige arealer |  | 10d | 2024-06-28 | 2024-08-08 | 54 | 139d | 0d |  |
| 56 | 7.3 | Overtagelse alle fag |  | 5d | 2024-08-09 | 2024-08-15 | 55 | 139d |  | start no earlier than 2023-12-11 |
